# TECH2 SCHED

Schedule from MS Project, 2005-11-18 to 2006-12-01.
ae

## Calendars

- Standard: Mon-Fri 08:00-12:00, 13:00-17:00; Sat-Sun off.

## Schedule

| ID | Task | Type | Duration | Start | Finish | Total slack | Constraint |
| --- | --- | --- | --- | --- | --- | --- | --- |
| 1 | PERMITS-PERMITS |  | 215d | 2005-11-18 | 2006-09-14 | 37d | start no earlier than 2005-11-18 |
| 2 | SUBMIT SITE IMPROVEMENTS PERMIT #1 | milestone | 0d | 2005-11-18 | 2005-11-18 | 271d | start no earlier than 2005-11-18 |
| 3 | MDC BUILDING DEPT. SITE IMPROVEMENTS PERMIT #1 |  | 42d | 2005-11-21 | 2006-01-17 | 228d | start no earlier than 2005-11-21 |
| 4 | WASD CONTRACT PLAN PROCEEDURE |  | 45d | 2005-12-05 | 2006-02-03 | 215d | start no earlier than 2005-12-05 |
| 5 | SFWM ERP PERMIT MODIFICATION |  | 90d | 2005-12-05 | 2006-04-07 | 170d | start no earlier than 2005-12-05 |
| 6 | SUBMIT BUILDING PERMIT #2 | milestone | 0d | 2005-12-14 | 2005-12-14 | 253d | start no earlier than 2005-12-14 |
| 7 | MDC BUILDING DEPT. REVIEW BUILDING PERMIT #2 |  | 42d | 2005-12-15 | 2006-02-10 | 210d | start no earlier than 2005-12-15 |
| 8 | DRY UTILITY NOTIFICATION | milestone | 0d | 2006-01-03 | 2006-01-03 | 239d | start no earlier than 2006-01-03 |
| 9 | RECEIVE SITEWORK PERMIT #1 | milestone | 0d | 2006-04-03 | 2006-04-03 | 175d | start no earlier than 2006-04-03 |
| 10 | RECEIVE BUILDING PERMIT #2 | milestone | 0d | 2006-06-30 | 2006-06-30 | 111d | start no earlier than 2006-06-30 |
| 11 | FINAL WASD APPROVAL REVIEW |  | 15d | 2006-08-22 | 2006-09-11 | 59d | start no earlier than 2006-08-22 |
| 12 | DERM SEWAR CONNECTION PERMIT REVIEW |  | 5d | 2006-09-08 | 2006-09-14 | 56d | start no earlier than 2006-09-08 |
| 13 | MDC HRS WATER CONNECTION PERMIT REVIEW |  | 5d | 2006-09-08 | 2006-09-14 | 56d | start no earlier than 2006-09-08 |
| 14 | DERM SEWAR CONNECTION PERMIT | milestone | 0d | 2006-09-14 | 2006-09-14 | 57d | start no earlier than 2006-09-14 |
| 15 | MIAMI DADE COUNTY HRS WATER CONNECTION | milestone | 0d | 2006-09-14 | 2006-09-14 | 57d | start no earlier than 2006-09-14 |
| 16 | SITE-SITE WORK |  | 116d | 2006-05-22 | 2006-10-30 | 24d | start no earlier than 2006-05-22 |
| 17 | MOBILIZATION | milestone | 0d | 2006-05-22 | 2006-05-22 | 140d | start no earlier than 2006-05-22 |
| 18 | INSTALL CONSTRUCTION FENCING & GATES |  | 5d | 2006-05-22 | 2006-05-26 | 135d | start no earlier than 2006-05-22 |
| 19 | INSTALL ENVIRONMENTAL/ EROSION CONTROL |  | 6d | 2006-06-02 | 2006-06-09 | 125d | start no earlier than 2006-06-02 |
| 20 | EXISTING LANDSCAPE REMOVAL |  | 5d | 2006-06-12 | 2006-06-16 | 120d | start no earlier than 2006-06-12 |
| 21 | REMOVE/ RELOCATE ELECTRICAL LINES |  | 15d | 2006-07-05 | 2006-07-25 | 93d | start no earlier than 2006-07-05 |
| 22 | REMOVE EXISTING PAVING |  | 10d | 2006-07-05 | 2006-07-18 | 98d | start no earlier than 2006-07-05 |
| 23 | REMOVAL/ RELOCATION OF INLETS & SITE DRAINAGE |  | 20d | 2006-07-17 | 2006-08-11 | 80d | start no earlier than 2006-07-17 |
| 24 | START BASS PRO SHOP SITE WORK | milestone | 0d | 2006-08-21 | 2006-08-21 | 75d | start no earlier than 2006-08-21 |
| 25 | REMOVE/ RELOCATE EXISTING ELEC SERVICE METERS |  | 5d | 2006-08-22 | 2006-08-28 | 69d | start no earlier than 2006-08-22 |
| 26 | TRANSFORMER PAD & PIPING |  | 15d | 2006-08-22 | 2006-09-11 | 59d | start no earlier than 2006-08-22 |
| 27 | BASS PRO SHOP PAD PREP |  | 22d | 2006-08-22 | 2006-09-20 | 52d | start no earlier than 2006-08-22 |
| 28 | INSTALL PARKING LIGHT FIXTURES |  | 10d | 2006-08-28 | 2006-09-08 | 60d | start no earlier than 2006-08-28 |
| 29 | REMOVAL/ RELOCATION OF EXISTING WATER SERVICE |  | 35d | 2006-09-08 | 2006-10-26 | 26d | start no earlier than 2006-09-08 |
| 30 | RELOCATION OF FIRE HYDRANT |  | 5d | 2006-09-14 | 2006-09-20 | 52d | start no earlier than 2006-09-14 |
| 31 | BASS PRO PAD CERTIFICATION |  | 12d | 2006-09-19 | 2006-10-04 | 42d | start no earlier than 2006-09-19 |
| 32 | REPAVING & STRIPPING OF SOUTH PARKING AREA |  | 10d | 2006-09-20 | 2006-10-03 | 43d | start no earlier than 2006-09-20 |
| 33 | INSTALL NEW CURBING AT PARKING AREAS |  | 5d | 2006-09-25 | 2006-09-29 | 45d | start no earlier than 2006-09-25 |
| 34 | BASS PRO SHOP PAD TURNOVER | milestone | 0d | 2006-10-02 | 2006-10-02 | 45d | start no earlier than 2006-10-02 |
| 35 | BASS PRO SHOP SITEWORK COMPLETED | milestone | 0d | 2006-10-02 | 2006-10-02 | 45d | start no earlier than 2006-10-02 |
| 36 | LANDSCAPING |  | 10d | 2006-10-12 | 2006-10-25 | 27d | start no earlier than 2006-10-12 |
| 37 | RELOCATION OF IRRIGATION SYSTEM |  | 5d | 2006-10-19 | 2006-10-25 | 27d | start no earlier than 2006-10-19 |
| 38 | INSTALL RING ROAD CURBING & PAVING |  | 10d | 2006-10-19 | 2006-11-01 | 22d | start no earlier than 2006-10-19 |
| 39 | BASS PRO SHOP-BOAT STORAGE |  | 111d | 2006-06-05 | 2006-11-06 | 19d | start no earlier than 2006-06-05 |
| 40 | MOBILIZATION | milestone | 0d | 2006-06-05 | 2006-06-05 | 130d | start no earlier than 2006-06-05 |
| 41 | INSTALL CONSTRUCTION FENCE & GATE |  | 5d | 2006-06-12 | 2006-06-16 | 120d | start no earlier than 2006-06-12 |
| 42 | ROUGH GRADE SITE |  | 15d | 2006-06-19 | 2006-07-07 | 105d | start no earlier than 2006-06-19 |
| 43 | RUN ELECTRICAL SERVICE FROM MALL |  | 20d | 2006-07-14 | 2006-08-10 | 81d | start no earlier than 2006-07-14 |
| 44 | INSTALL SITE DRAINAGE SYSTEM |  | 10d | 2006-07-17 | 2006-07-28 | 90d | start no earlier than 2006-07-17 |
| 45 | EXCAVATE/ INSTALL CONCRETE FOOTINGS |  | 15d | 2006-08-07 | 2006-08-25 | 70d | start no earlier than 2006-08-07 |
| 46 | CONSTRUCT MASONRY BOAT STORAGE ENCLOSURE |  | 30d | 2006-08-16 | 2006-09-26 | 48d | start no earlier than 2006-08-16 |
| 47 | COMPLETE ELECTRICAL SERVICE |  | 5d | 2006-09-14 | 2006-09-20 | 52d | start no earlier than 2006-09-14 |
| 48 | INSTALL SITE LIGHTING |  | 5d | 2006-09-14 | 2006-09-20 | 52d | start no earlier than 2006-09-14 |
| 49 | INSTALL WATER & SEWAR LINE |  | 20d | 2006-09-14 | 2006-10-11 | 37d | start no earlier than 2006-09-14 |
| 50 | FOOTING & MASONRY WALL AT WATER LINE |  | 15d | 2006-10-09 | 2006-10-27 | 25d | start no earlier than 2006-10-09 |
| 51 | PROVIDE ROAD CUTTING & FINAL GRADING |  | 5d | 2006-10-19 | 2006-10-25 | 27d | start no earlier than 2006-10-19 |
| 52 | PAVING |  | 5d | 2006-10-25 | 2006-10-31 | 23d | start no earlier than 2006-10-25 |
| 53 | INSTALL ENTRY GATES |  | 5d | 2006-10-31 | 2006-11-06 | 19d | start no earlier than 2006-10-31 |
| 54 | LANDSCAPPING |  | 5d | 2006-10-31 | 2006-11-06 | 19d | start no earlier than 2006-10-31 |
| 55 | BOAT STORAGE COMPLETED | milestone | 0d | 2006-11-06 | 2006-11-06 | 20d | start no earlier than 2006-11-06 |
| 56 | DEMO-DEMOLITION |  | 44d | 2006-07-10 | 2006-09-07 | 61d | start no earlier than 2006-07-10 |
| 57 | MOBILIZATION | milestone | 0d | 2006-07-10 | 2006-07-10 | 105d | start no earlier than 2006-07-10 |
| 58 | SELECTIVE DEMOLITION |  | 10d | 2006-07-10 | 2006-07-21 | 95d | start no earlier than 2006-07-10 |
| 59 | SAFE OFF RELOCATE EXISITING UTILITIES |  | 10d | 2006-07-10 | 2006-07-21 | 95d | start no earlier than 2006-07-10 |
| 60 | CUT IN DOORS & SUPPORT STEEL @ TILT UP PANELS |  | 10d | 2006-07-12 | 2006-07-25 | 93d | start no earlier than 2006-07-12 |
| 61 | FRAMING/ SHEATHING TEMP CORRIDOR NORTH |  | 15d | 2006-07-17 | 2006-08-04 | 85d | start no earlier than 2006-07-17 |
| 62 | FRAMING/ SHEATHING TEMP CORRIDOR SOUTH |  | 15d | 2006-07-17 | 2006-08-04 | 85d | start no earlier than 2006-07-17 |
| 63 | REMOVAL OF EXISTING SLAB, FOOTINGS & PILES |  | 15d | 2006-07-17 | 2006-08-04 | 85d | start no earlier than 2006-07-17 |
| 64 | REMOVAL EXISTING UTILITIES & RTU 2A |  | 5d | 2006-07-20 | 2006-07-26 | 92d | start no earlier than 2006-07-20 |
| 65 | ELECTRICAL/ FIRE ALARM IN NORTH CORRIDOR |  | 5d | 2006-08-07 | 2006-08-11 | 80d | start no earlier than 2006-08-07 |
| 66 | FIRE PROTECTION NORTH CORRIDOR |  | 5d | 2006-08-07 | 2006-08-11 | 80d | start no earlier than 2006-08-07 |
| 67 | ELECTRICAL/ FIRE ALARM IN SOUTH CORRIDOR |  | 5d | 2006-08-07 | 2006-08-11 | 80d | start no earlier than 2006-08-07 |
| 68 | FIRE PROTECTION SOUTH CORRIDOR |  | 5d | 2006-08-07 | 2006-08-11 | 80d | start no earlier than 2006-08-07 |
| 69 | DEMOLITION OF EXISITING EXTERIOR SHELL |  | 15d | 2006-08-21 | 2006-09-08 | 60d | start no earlier than 2006-08-21 |
| 70 | CUT BACK EXISITING ROOFING |  | 10d | 2006-08-28 | 2006-09-08 | 60d | start no earlier than 2006-08-28 |

| ID | Task | Type | Duration | Start | Finish | Total slack | Constraint |
| --- | --- | --- | --- | --- | --- | --- | --- |
| 71 | TEMPORARY PROTECTION EXISITING MALL EXTERIOR |  | 10d | 2006-08-28 | 2006-09-08 | 60d | start no earlier than 2006-08-28 |
| 72 | TEMPORARY EXTERIOR WALL AT COURT #1 |  | 10d | 2006-08-28 | 2006-09-08 | 60d | start no earlier than 2006-08-28 |
| 73 | MC-MALL RECONFIGURATION |  | 95d | 2006-07-24 | 2006-12-01 | 0d | start no earlier than 2006-07-24 |
| 74 | EXCAVATIONS FOR FOOTINGS & FOUNDATION |  | 10d | 2006-07-24 | 2006-08-04 | 85d | start no earlier than 2006-07-24 |
| 75 | INSTALL MASONRY WALL, COLUMN FOOTINGS & SLAB |  | 10d | 2006-08-03 | 2006-08-16 | 77d | start no earlier than 2006-08-03 |
| 76 | CONSTRUCT NEW MASONRY DEMISING PARTITION |  | 30d | 2006-08-28 | 2006-10-06 | 40d | start no earlier than 2006-08-28 |
| 77 | ERECTION OF NEW STRUCTURAL STEEL & ROOF DECKING |  | 15d | 2006-09-25 | 2006-10-13 | 35d | start no earlier than 2006-09-25 |
| 78 | RELOCATION/ ADDITION OF ROOF DRAINAGE |  | 10d | 2006-10-12 | 2006-10-25 | 27d | start no earlier than 2006-10-12 |
| 79 | INSTALL NEW ROOFING |  | 15d | 2006-10-12 | 2006-11-01 | 22d | start no earlier than 2006-10-12 |
| 80 | ROOF TIE IN AT EXTERIOR WALL |  | 5d | 2006-10-24 | 2006-10-30 | 24d | start no earlier than 2006-10-24 |
| 81 | EXTERIOR FINISH OF MASONRY PARTITION |  | 5d | 2006-10-30 | 2006-11-03 | 20d | start no earlier than 2006-10-30 |
| 82 | RELOCATION OF RTU 2A |  | 5d | 2006-10-30 | 2006-11-03 | 20d | start no earlier than 2006-10-30 |
| 83 | CONSTRUCT BULK HEAD PARTITION |  | 10d | 2006-10-30 | 2006-11-10 | 15d | start no earlier than 2006-10-30 |
| 84 | CONSTRUCT NEW DRYWALL CORRIDOR PARTITION |  | 15d | 2006-10-30 | 2006-11-17 | 10d | start no earlier than 2006-10-30 |
| 85 | INSTALL NEW ROOF TOP UNIT RT2B |  | 5d | 2006-11-01 | 2006-11-07 | 18d | start no earlier than 2006-11-01 |
| 86 | INSTALL NEW SPRINKLER SYSTEM |  | 10d | 2006-11-06 | 2006-11-17 | 10d | start no earlier than 2006-11-06 |
| 87 | INSTALL LIGHTING & FIRE ALARM IN NEW CORRIDOR |  | 10d | 2006-11-06 | 2006-11-17 | 10d | start no earlier than 2006-11-06 |
| 88 | EXTEND HVAC SYSTEM |  | 5d | 2006-11-10 | 2006-11-16 | 11d | start no earlier than 2006-11-10 |
| 89 | COLOT CONCRETE FLOORING AT ENTRY #1 |  | 2d | 2006-10-10 | 2006-10-11 | 37d | start no earlier than 2006-10-10 |
| 90 | FINISH CORRIDOR WALLS |  | 5d | 2006-11-13 | 2006-11-17 | 10d | start no earlier than 2006-11-13 |
| 91 | INSTALL SIGNAGE |  | 2d | 2006-11-14 | 2006-11-15 | 12d | start no earlier than 2006-11-14 |
| 92 | RECEIVE CERTIFICATE OF OCCUPANCY | milestone | 0d | 2006-11-17 | 2006-11-17 | 11d | start no earlier than 2006-11-17 |
| 93 | REMOVE TEMPORARY PEDESTRIAN CORRIDORS |  | 10d | 2006-11-20 | 2006-12-01 | 0d | start no earlier than 2006-11-20 |
| 94 | TEMPORARY PARTITIONS AT ENTRY #1 |  | 5d | 2006-11-27 | 2006-12-01 | 0d | start no earlier than 2006-11-27 |
| 95 | INSTALL DOORS & HW AT CORRIDOR AND PARTITION |  | 2d | 2006-11-30 | 2006-12-01 | 0d | start no earlier than 2006-11-30 |
| 96 | COMPLETION OF MALL RECONFIGURATION | milestone | 0d | 2006-12-01 | 2006-12-01 | 1d | start no earlier than 2006-12-01 |
| 97 | ID-INFORMATION DESK RELOCATION |  | 15d | 2006-08-28 | 2006-09-15 | 55d | start no earlier than 2006-08-28 |
| 98 | RELOCATION OF ELECTRICAL/ TELCOM COURT #2 |  | 6d | 2006-08-28 | 2006-09-04 | 64d | start no earlier than 2006-08-28 |
| 99 | PATCH EXISITING CONCRETE SLAB & STAIN |  | 2d | 2006-09-04 | 2006-09-05 | 63d | start no earlier than 2006-09-04 |
| 100 | DISASSEMBLE EXISITING INFO DESK AT COURT #1 |  | 5d | 2006-09-06 | 2006-09-12 | 58d | start no earlier than 2006-09-06 |
| 101 | REINSTALL INFO DESK AT COURT #2 |  | 5d | 2006-09-12 | 2006-09-18 | 54d | start no earlier than 2006-09-12 |
| 102 | CONSTRUCT TEMPORARY PARTITION AT ENTRY #1 |  | 3d | 2006-09-12 | 2006-09-14 | 56d | start no earlier than 2006-09-12 |
| 103 | FINAL CONNECTIONS/ MOVE IN |  | 2d | 2006-09-18 | 2006-09-19 | 53d | start no earlier than 2006-09-18 |
| 104 | COMPLETE RELOCATION OF INFO DESK | milestone | 0d | 2006-10-27 | 2006-10-27 | 26d |  |
