# TECH2 SCHEDactuaMODIFIEDl

Schedule from MS Project, 2005-11-18 to 2007-01-30.
ae

## Calendars

- Standard: Mon-Fri 08:00-12:00, 13:00-17:00; Sat-Sun off.

## Schedule

| ID | Task | Type | Duration | Start | Finish | Total slack | Constraint |
| --- | --- | --- | --- | --- | --- | --- | --- |
| 1 | PERMITS-PERMITS |  | 222d | 2005-11-18 | 2006-09-25 | 91d | start no earlier than 2005-11-18 |
| 2 | PERMITS-PERMITS MODIFIED |  | 200d | 2005-11-18 | 2006-08-24 | 113d | start no earlier than 2005-11-18 |
| 3 | SUBMIT SITE IMPROVEMENTS PERMIT #1 | milestone | 0d | 2005-11-18 | 2005-11-18 | 313d | start no earlier than 2005-11-18 |
| 4 | SUBMIT SITE IMPROVEMENTS PERMIT #1 MODIFIED | milestone | 0d | 2005-11-18 | 2005-11-18 | 313d | start no earlier than 2005-11-18 |
| 5 | MDC BUILDING DEPT. SITE IMPROVEMENTS PERMIT #1 |  | 42d | 2005-11-21 | 2006-01-17 | 270d | start no earlier than 2005-11-21 |
| 6 | MDC BUILDING DEPT. SITE IMPROVEMENTS PERMIT #1 MODIFIED |  | 42d | 2005-11-21 | 2006-01-17 | 270d | start no earlier than 2005-11-21 |
| 7 | WASD CONTRACT PLAN PROCEEDURE |  | 45d | 2005-12-05 | 2006-02-03 | 257d | start no earlier than 2005-12-05 |
| 8 | WASD CONTRACT PLAN PROCEEDURE MODIFIED |  | 45d | 2005-12-05 | 2006-02-03 | 257d | start no earlier than 2005-12-05 |
| 9 | SFWM ERP PERMIT MODIFICATION |  | 90d | 2005-12-05 | 2006-04-07 | 212d | start no earlier than 2005-12-05 |
| 10 | SFWM ERP PERMIT MODIFICATION MODIFIED |  | 90d | 2005-12-05 | 2006-04-07 | 212d | start no earlier than 2005-12-05 |
| 11 | SUBMIT BUILDING PERMIT #2 | milestone | 0d | 2005-12-14 | 2005-12-14 | 295d | start no earlier than 2005-12-14 |
| 12 | SUBMIT BUILDING PERMIT #2 MODIFIED | milestone | 0d | 2005-12-14 | 2005-12-14 | 295d | start no earlier than 2005-12-14 |
| 13 | MDC BUILDING DEPT. REVIEW BUILDING PERMIT #2 |  | 42d | 2005-12-15 | 2006-02-10 | 252d | start no earlier than 2005-12-15 |
| 14 | MDC BUILDING DEPT. REVIEW BUILDING PERMIT #2 MODIFIED |  | 30d | 2005-12-15 | 2006-01-25 | 264d | start no earlier than 2005-12-15 |
| 15 | MDC BUILDING DEPT. REVIEW BUILDING PERMIT #2 RESUBMISSION |  | 15d | 2006-07-31 | 2006-08-18 | 117d | start no earlier than 2006-07-31 |
| 16 | MDC BUILDING DEPT. REVIEW BUILDING PERMIT #2 RESUBMISSION MODIFIED |  | 10d | 2006-07-03 | 2006-07-14 | 142d | start no earlier than 2006-07-03 |
| 17 | DRY UTILITY NOTIFICATION | milestone | 0d | 2006-01-03 | 2006-01-03 | 281d | start no earlier than 2006-01-03 |
| 18 | DRY UTILITY NOTIFICATION MODIFIED | milestone | 0d | 2006-01-03 | 2006-01-03 | 281d | start no earlier than 2006-01-03 |
| 19 | RECEIVE SITEWORK PERMIT #1 | milestone | 0d | 2006-04-03 | 2006-04-03 | 217d | start no earlier than 2006-04-03 |
| 20 | RECEIVE SITEWORK PERMIT #1 MODIFIED | milestone | 0d | 2006-04-03 | 2006-04-03 | 217d | start no earlier than 2006-04-03 |
| 21 | RECEIVE BUILDING PERMIT #2 | milestone | 0d | 2006-06-30 | 2006-06-30 | 153d | start no earlier than 2006-06-30 |
| 22 | RECEIVE BUILDING PERMIT #2 MODIFIED | milestone | 0d | 2006-06-30 | 2006-06-30 | 153d | start no earlier than 2006-06-30 |
| 23 | RECEIVE BUILDING PERMIT #2 RESUBMISSION | milestone | 0d | 2006-08-18 | 2006-08-18 | 118d | start no earlier than 2006-08-18 |
| 24 | RECEIVE BUILDING PERMIT #2 RESUBMISSION MODIFIED | milestone | 0d | 2006-07-17 | 2006-07-17 | 142d | start no earlier than 2006-07-17 |
| 25 | FINAL WASD APPROVAL REVIEW |  | 25d | 2006-08-22 | 2006-09-25 | 91d | finish no earlier than 2006-09-25 |
| 26 | FINAL WASD APPROVAL REVIEW MODIFIED |  | 25d | 2006-07-21 | 2006-08-24 | 113d | start no earlier than 2006-07-21 |
| 27 | DERM SEWAR CONNECTION PERMIT REVIEW |  | 10d | 2006-09-08 | 2006-09-21 | 93d | start no earlier than 2006-09-08 |
| 28 | DERM SEWAR CONNECTION PERMIT REVIEW MODIFIED |  | 10d | 2006-07-21 | 2006-08-03 | 128d | start no earlier than 2006-07-21 |
| 29 | MDC HRS WATER CONNECTION PERMIT REVIEW |  | 10d | 2006-09-08 | 2006-09-21 | 93d | start no earlier than 2006-09-08 |
| 30 | MDC HRS WATER CONNECTION PERMIT REVIEW MODIFIED |  | 10d | 2006-07-21 | 2006-08-03 | 128d | start no earlier than 2006-07-21 |
| 31 | DERM SEWAR CONNECTION PERMIT | milestone | 0d | 2006-09-21 | 2006-09-21 | 94d | start no earlier than 2006-09-21 |
| 32 | DERM SEWAR CONNECTION PERMIT MODIFIED | milestone | 0d | 2006-07-21 | 2006-07-21 | 138d | start no earlier than 2006-07-21 |
| 33 | MIAMI DADE COUNTY HRS WATER CONNECTION | milestone | 0d | 2006-09-25 | 2006-09-25 | 92d | start no earlier than 2006-09-25 |
| 34 | MIAMI DADE COUNTY HRS WATER CONNECTION MODIFIED | milestone | 0d | 2006-08-24 | 2006-08-24 | 114d | start no earlier than 2006-08-24 |
| 35 | SITE-SITE WORK |  | 139d | 2006-05-22 | 2006-11-30 | 43d | start no earlier than 2006-05-22 |
| 36 | SITE-SITE WORK MODIFIED |  | 116d | 2006-05-22 | 2006-10-30 | 66d | start no earlier than 2006-05-22 |
| 37 | MOBILIZATION | milestone | 0d | 2006-05-22 | 2006-05-22 | 182d | start no earlier than 2006-05-22 |
| 38 | MOBILIZATION MODIFIED | milestone | 0d | 2006-05-22 | 2006-05-22 | 182d | start no earlier than 2006-05-22 |
| 39 | INSTALL CONSTRUCTION FENCING & GATES |  | 5d | 2006-05-22 | 2006-05-26 | 177d | start no earlier than 2006-05-22 |
| 40 | INSTALL CONSTRUCTION FENCING & GATES MODIFIED |  | 5d | 2006-05-22 | 2006-05-26 | 177d | start no earlier than 2006-05-22 |
| 41 | INSTALL ENVIRONMENTAL/ EROSION CONTROL |  | 6d | 2006-06-02 | 2006-06-09 | 167d | start no earlier than 2006-06-02 |
| 42 | INSTALL ENVIRONMENTAL/ EROSION CONTROL MODIFIED |  | 6d | 2006-06-02 | 2006-06-09 | 167d | start no earlier than 2006-06-02 |
| 43 | EXISTING LANDSCAPE REMOVAL |  | 5d | 2006-06-12 | 2006-06-16 | 162d | start no earlier than 2006-06-12 |
| 44 | EXISTING LANDSCAPE REMOVAL MODIFIED |  | 5d | 2006-06-12 | 2006-06-16 | 162d | start no earlier than 2006-06-12 |
| 45 | REMOVE/ RELOCATE ELECTRICAL LINES |  | 15d | 2006-07-05 | 2006-07-25 | 135d | start no earlier than 2006-07-05 |
| 46 | REMOVE/ RELOCATE ELECTRICAL LINES MODIFIED |  | 15d | 2006-07-05 | 2006-07-25 | 135d | start no earlier than 2006-07-05 |
| 47 | REMOVE EXISTING PAVING |  | 10d | 2006-07-05 | 2006-07-18 | 140d | start no earlier than 2006-07-05 |
| 48 | REMOVE EXISTING PAVING MODIFIED |  | 10d | 2006-07-05 | 2006-07-18 | 140d | start no earlier than 2006-07-05 |
| 49 | REMOVAL/ RELOCATION OF INLETS & SITE DRAINAGE |  | 20d | 2006-07-17 | 2006-08-11 | 122d | start no earlier than 2006-07-17 |
| 50 | REMOVAL/ RELOCATION OF INLETS & SITE DRAINAGE MODIFIED |  | 20d | 2006-07-17 | 2006-08-11 | 122d | start no earlier than 2006-07-17 |
| 51 | START BASS PRO SHOP SITE WORK | milestone | 0d | 2006-08-21 | 2006-08-21 | 117d | start no earlier than 2006-08-21 |
| 52 | START BASS PRO SHOP SITE WORK MODIFIED | milestone | 0d | 2006-08-04 | 2006-08-04 | 128d | start no earlier than 2006-08-04 |
| 53 | REMOVE/ RELOCATE EXISTING ELEC SERVICE METERS |  | 5d | 2006-08-22 | 2006-08-28 | 111d | start no earlier than 2006-08-22 |
| 54 | REMOVE/ RELOCATE EXISTING ELEC SERVICE METERS MODIFIED |  | 5d | 2006-08-07 | 2006-08-11 | 122d | start no earlier than 2006-08-07 |
| 55 | TRANSFORMER PAD & PIPING |  | 15d | 2006-08-22 | 2006-09-11 | 101d | start no earlier than 2006-08-22 |
| 56 | TRANSFORMER PAD & PIPING MODIFIED |  | 15d | 2006-08-14 | 2006-09-01 | 107d | start no earlier than 2006-08-14 |
| 57 | BASS PRO SHOP PAD PREP |  | 22d | 2006-08-22 | 2006-09-20 | 94d | start no earlier than 2006-08-22 |
| 58 | BASS PRO SHOP PAD PREP MODIFIED |  | 22d | 2006-08-04 | 2006-09-04 | 106d | start no earlier than 2006-08-04 |
| 59 | INSTALL PARKING LIGHT FIXTURES |  | 10d | 2006-08-28 | 2006-09-08 | 102d | start no earlier than 2006-08-28 |
| 60 | INSTALL PARKING LIGHT FIXTURES MODIFIED |  | 10d | 2006-08-14 | 2006-08-25 | 112d | start no earlier than 2006-08-14 |
| 61 | REMOVAL/ RELOCATION OF EXISTING WATER SERVICE |  | 35d | 2006-09-26 | 2006-11-13 | 56d | start no earlier than 2006-09-26 |
| 62 | REMOVAL/ RELOCATION OF EXISTING WATER SERVICE MODIFIED |  | 35d | 2006-08-25 | 2006-10-12 | 78d | start no earlier than 2006-08-25 |
| 63 | RELOCATION OF FIRE HYDRANT |  | 5d | 2006-09-14 | 2006-09-20 | 94d | start no earlier than 2006-09-14 |
| 64 | RELOCATION OF FIRE HYDRANT MODIFIED |  | 5d | 2006-08-30 | 2006-09-05 | 105d | start no earlier than 2006-08-30 |
| 65 | BASS PRO PAD CERTIFICATION |  | 12d | 2006-11-14 | 2006-11-29 | 44d | start no earlier than 2006-11-14 |
| 66 | BASS PRO PAD CERTIFICATION MODIFIED |  | 12d | 2006-10-13 | 2006-10-30 | 66d | start no earlier than 2006-10-13 |
| 67 | REPAVING & STRIPPING OF SOUTH PARKING AREA |  | 10d | 2006-09-29 | 2006-10-12 | 78d | start no earlier than 2006-09-29 |
| 68 | REPAVING & STRIPPING OF SOUTH PARKING AREA MODIFIED |  | 10d | 2006-09-15 | 2006-09-28 | 88d | start no earlier than 2006-09-15 |
| 69 | INSTALL NEW CURBING AT PARKING AREAS |  | 5d | 2006-09-29 | 2006-10-05 | 83d | start no earlier than 2006-09-29 |
| 70 | INSTALL NEW CURBING AT PARKING AREAS MODIFIED |  | 5d | 2006-09-15 | 2006-09-21 | 93d | start no earlier than 2006-09-15 |

| ID | Task | Type | Duration | Start | Finish | Total slack | Constraint |
| --- | --- | --- | --- | --- | --- | --- | --- |
| 71 | BASS PRO SHOP PAD TURNOVER | milestone | 0d | 2006-11-29 | 2006-11-29 | 45d | start no earlier than 2006-11-29 |
| 72 | BASS PRO SHOP PAD TURNOVER MODIFIED | milestone | 0d | 2006-10-30 | 2006-10-30 | 67d | start no earlier than 2006-10-30 |
| 73 | BASS PRO SHOP SITEWORK COMPLETED | milestone | 0d | 2006-11-29 | 2006-11-29 | 45d | start no earlier than 2006-11-29 |
| 74 | BASS PRO SHOP SITEWORK COMPLETED MODIFIED | milestone | 0d | 2006-10-30 | 2006-10-30 | 67d | start no earlier than 2006-10-30 |
| 75 | LANDSCAPING |  | 15d | 2006-11-06 | 2006-11-24 | 47d | start no earlier than 2006-11-06 |
| 76 | LANDSCAPING MODIFIED |  | 15d | 2006-09-15 | 2006-10-05 | 83d | start no earlier than 2006-09-15 |
| 77 | RELOCATION OF IRRIGATION SYSTEM |  | 10d | 2006-10-19 | 2006-11-01 | 64d | start no earlier than 2006-10-19 |
| 78 | RELOCATION OF IRRIGATION SYSTEM MODIFIED |  | 10d | 2006-10-02 | 2006-10-13 | 77d | start no earlier than 2006-10-02 |
| 79 | INSTALL RING ROAD CURBING & PAVING |  | 10d | 2006-11-16 | 2006-11-29 | 44d | start no earlier than 2006-11-16 |
| 80 | INSTALL RING ROAD CURBING & PAVING MODIFIED |  | 10d | 2006-10-09 | 2006-10-20 | 72d | start no earlier than 2006-10-09 |
| 81 | BASS PRO SHOP-BOAT STORAGE |  | 113d | 2006-06-05 | 2006-11-08 | 59d | start no earlier than 2006-06-05 |
| 82 | BASS PRO SHOP-BOAT STORAGE MODIFIED |  | 99d | 2006-06-05 | 2006-10-19 | 73d | start no earlier than 2006-06-05 |
| 83 | MOBILIZATION | milestone | 0d | 2006-06-05 | 2006-06-05 | 172d | start no earlier than 2006-06-05 |
| 84 | MOBILIZATION MODIFIED | milestone | 0d | 2006-06-05 | 2006-06-05 | 172d | start no earlier than 2006-06-05 |
| 85 | INSTALL CONSTRUCTION FENCE & GATE |  | 5d | 2006-06-12 | 2006-06-16 | 162d | start no earlier than 2006-06-12 |
| 86 | INSTALL CONSTRUCTION FENCE & GATE MODIFIED |  | 5d | 2006-06-12 | 2006-06-16 | 162d | start no earlier than 2006-06-12 |
| 87 | ROUGH GRADE SITE |  | 15d | 2006-06-19 | 2006-07-07 | 147d | start no earlier than 2006-06-19 |
| 88 | ROUGH GRADE SITE MODIFIED |  | 15d | 2006-06-19 | 2006-07-07 | 147d | start no earlier than 2006-06-19 |
| 89 | RUN ELECTRICAL SERVICE FROM MALL |  | 20d | 2006-07-14 | 2006-08-10 | 123d | start no earlier than 2006-07-14 |
| 90 | RUN ELECTRICAL SERVICE FROM MALL MODIFIED |  | 20d | 2006-07-14 | 2006-08-10 | 123d | start no earlier than 2006-07-14 |
| 91 | INSTALL SITE DRAINAGE SYSTEM |  | 10d | 2006-07-17 | 2006-07-28 | 132d | start no earlier than 2006-07-17 |
| 92 | INSTALL SITE DRAINAGE SYSTEM MODIFIED |  | 10d | 2006-07-17 | 2006-07-28 | 132d | start no earlier than 2006-07-17 |
| 93 | EXCAVATE/ INSTALL CONCRETE FOOTINGS |  | 25d | 2006-08-07 | 2006-09-08 | 102d | start no earlier than 2006-08-07 |
| 94 | EXCAVATE/ INSTALL CONCRETE FOOTINGS MODIFIED |  | 25d | 2006-08-07 | 2006-09-08 | 102d | start no earlier than 2006-08-07 |
| 95 | CONSTRUCT MASONRY BOAT STORAGE ENCLOSURE |  | 30d | 2006-09-11 | 2006-10-20 | 72d | start no earlier than 2006-09-11 |
| 96 | CONSTRUCT MASONRY BOAT STORAGE ENCLOSURE MODIFIED |  | 30d | 2006-09-11 | 2006-10-20 | 72d | start no earlier than 2006-09-11 |
| 97 | COMPLETE ELECTRICAL SERVICE |  | 5d | 2006-09-28 | 2006-10-04 | 84d | start no earlier than 2006-09-28 |
| 98 | COMPLETE ELECTRICAL SERVICE MODIFIED |  | 5d | 2006-09-28 | 2006-10-04 | 84d | start no earlier than 2006-09-28 |
| 99 | INSTALL SITE LIGHTING |  | 5d | 2006-09-28 | 2006-10-04 | 84d | start no earlier than 2006-09-28 |
| 100 | INSTALL SITE LIGHTING MODIFIED |  | 5d | 2006-09-28 | 2006-10-04 | 84d | start no earlier than 2006-09-28 |
| 101 | INSTALL WATER & SEWAR LINE |  | 20d | 2006-09-21 | 2006-10-18 | 74d | start no earlier than 2006-09-21 |
| 102 | INSTALL WATER & SEWAR LINE MODIFIED |  | 20d | 2006-08-28 | 2006-09-22 | 92d | start no earlier than 2006-08-28 |
| 103 | FOOTING & MASONRY WALL AT WATER LINE |  | 15d | 2006-10-09 | 2006-10-27 | 67d | start no earlier than 2006-10-09 |
| 104 | FOOTING & MASONRY WALL AT WATER LINE MODIFIED |  | 15d | 2006-09-15 | 2006-10-05 | 83d | start no earlier than 2006-09-15 |
| 105 | PROVIDE ROAD CUTTING & FINAL GRADING |  | 5d | 2006-10-26 | 2006-11-01 | 64d | start no earlier than 2006-10-26 |
| 106 | PROVIDE ROAD CUTTING & FINAL GRADING MODIFIED |  | 5d | 2006-10-06 | 2006-10-12 | 78d | start no earlier than 2006-10-06 |
| 107 | PAVING |  | 5d | 2006-11-02 | 2006-11-08 | 59d | start no earlier than 2006-11-02 |
| 108 | PAVING MODIFIED |  | 5d | 2006-10-13 | 2006-10-19 | 73d | start no earlier than 2006-10-13 |
| 109 | INSTALL ENTRY GATES |  | 5d | 2006-10-31 | 2006-11-06 | 61d | start no earlier than 2006-10-31 |
| 110 | INSTALL ENTRY GATES MODIFIED |  | 5d | 2006-10-13 | 2006-10-19 | 73d | start no earlier than 2006-10-13 |
| 111 | LANDSCAPPING |  | 10d | 2006-10-31 | 2006-11-13 | 56d | start no earlier than 2006-10-31 |
| 112 | LANDSCAPPING MODIFIED |  | 10d | 2006-09-25 | 2006-10-06 | 82d | start no earlier than 2006-09-25 |
| 113 | BOAT STORAGE COMPLETED | milestone | 0d | 2006-11-08 | 2006-11-08 | 60d | start no earlier than 2006-11-08 |
| 114 | BOAT STORAGE COMPLETED MODIFIED | milestone | 0d | 2006-10-19 | 2006-10-19 | 74d | start no earlier than 2006-10-19 |
| 115 | DEMO-DEMOLITION |  | 50d | 2006-07-10 | 2006-09-15 | 97d | start no earlier than 2006-07-10 |
| 116 | DEMO-DEMOLITION MODIFIED |  | 35d | 2006-07-03 | 2006-08-18 | 117d | start no earlier than 2006-07-03 |
| 117 | MOBILIZATION | milestone | 0d | 2006-07-10 | 2006-07-10 | 147d | start no earlier than 2006-07-10 |
| 118 | MOBILIZATION MODIFIED | milestone | 0d | 2006-07-03 | 2006-07-03 | 152d | start no earlier than 2006-07-03 |
| 119 | SELECTIVE DEMOLITION |  | 30d | 2006-07-10 | 2006-08-18 | 117d | start no earlier than 2006-07-10 |
| 120 | SELECTIVE DEMOLITION MODIFIED |  | 25d | 2006-07-10 | 2006-08-11 | 122d | start no earlier than 2006-07-10 |
| 121 | SAFE OFF RELOCATE EXISITING UTILITIES |  | 20d | 2006-07-10 | 2006-08-04 | 127d | start no earlier than 2006-07-10 |
| 122 | SAFE OFF RELOCATE EXISITING UTILITIES MODIFIED |  | 20d | 2006-07-10 | 2006-08-04 | 127d | start no earlier than 2006-07-10 |
| 123 | CUT IN DOORS & SUPPORT STEEL @ TILT UP PANELS |  | 10d | 2006-08-16 | 2006-08-29 | 110d | start no earlier than 2006-08-16 |
| 124 | CUT IN DOORS & SUPPORT STEEL @ TILT UP PANELS MODIFIED |  | 2d | 2006-08-16 | 2006-08-17 | 118d | start no earlier than 2006-08-16 |
| 125 | FRAMING/ SHEATHING TEMP CORRIDOR NORTH |  | 30d | 2006-07-17 | 2006-08-25 | 112d | start no earlier than 2006-07-17 |
| 126 | FRAMING/ SHEATHING TEMP CORRIDOR NORTH MODIFIED |  | 5d | 2006-07-17 | 2006-07-21 | 137d | start no earlier than 2006-07-17 |
| 127 | FRAMING/ SHEATHING TEMP CORRIDOR SOUTH |  | 30d | 2006-07-17 | 2006-08-25 | 112d | start no earlier than 2006-07-17 |
| 128 | FRAMING/ SHEATHING TEMP CORRIDOR SOUTH MODIFIED |  | 5d | 2006-07-17 | 2006-07-21 | 137d | start no earlier than 2006-07-17 |
| 129 | CONSTRUCT STRUCTURAL CAGE |  | 5d | 2006-07-10 | 2006-07-14 | 142d | start no earlier than 2006-07-10 |
| 130 | FRAMING/ SHEATHING TEMP CORRIDOR THROUGH CAGE |  | 10d | 2006-07-17 | 2006-07-28 | 132d | start no earlier than 2006-07-17 |
| 131 | REMOVAL OF EXISTING SLAB, FOOTINGS & PILES |  | 28d | 2006-07-17 | 2006-08-23 | 114d | start no earlier than 2006-07-17 |
| 132 | REMOVAL OF EXISTING SLAB, FOOTINGS & PILES MODIFIED |  | 15d | 2006-07-03 | 2006-07-21 | 137d | start no earlier than 2006-07-03 |
| 133 | REMOVAL EXISTING UTILITIES & RTU 2A |  | 15d | 2006-07-20 | 2006-08-09 | 124d | start no earlier than 2006-07-20 |
| 134 | REMOVAL EXISTING UTILITIES & RTU 2A MODIFIED |  | 15d | 2006-07-20 | 2006-08-09 | 124d | start no earlier than 2006-07-20 |
| 135 | ELECTRICAL/ FIRE ALARM IN NORTH CORRIDOR |  | 15d | 2006-08-28 | 2006-09-15 | 97d | start no earlier than 2006-08-28 |
| 136 | FIRE PROTECTION NORTH CORRIDOR |  | 15d | 2006-08-28 | 2006-09-15 | 97d | start no earlier than 2006-08-28 |
| 137 | ELECTRICAL/ FIRE ALARM IN SOUTH CORRIDOR |  | 15d | 2006-08-28 | 2006-09-15 | 97d | start no earlier than 2006-08-28 |
| 138 | FIRE PROTECTION SOUTH CORRIDOR |  | 15d | 2006-08-28 | 2006-09-15 | 97d | start no earlier than 2006-08-28 |
| 139 | ELECTRICAL/ FIRE ALARM TEMP CORRIDOR |  | 10d | 2006-07-31 | 2006-08-11 | 122d | start no earlier than 2006-07-31 |
| 140 | FIRE PROTECTION TEMP CORRIDOR |  | 15d | 2006-07-31 | 2006-08-18 | 117d | start no earlier than 2006-07-31 |

| ID | Task | Type | Duration | Start | Finish | Total slack | Constraint |
| --- | --- | --- | --- | --- | --- | --- | --- |
| 141 | DEMOLITION OF EXISITING EXTERIOR SHELL |  | 20d | 2006-08-21 | 2006-09-15 | 97d | start no earlier than 2006-08-21 |
| 142 | DEMOLITION OF EXISITING EXTERIOR SHELL MODIFIED |  | 20d | 2006-07-24 | 2006-08-18 | 117d | start no earlier than 2006-07-24 |
| 143 | CUT BACK EXISITING ROOFING |  | 10d | 2006-08-31 | 2006-09-13 | 99d | start no earlier than 2006-08-31 |
| 144 | CUT BACK EXISITING ROOFING MODIFIED |  | 10d | 2006-07-31 | 2006-08-11 | 122d | start no earlier than 2006-07-31 |
| 145 | TEMPORARY PROTECTION EXISITING MALL EXTERIOR |  | 10d | 2006-08-28 | 2006-09-08 | 102d | start no earlier than 2006-08-28 |
| 146 | TEMPORARY EXTERIOR WALL AT COURT #1 |  | 10d | 2006-08-28 | 2006-09-08 | 102d | start no earlier than 2006-08-28 |
| 147 | MC-MALL RECONFIGURATION |  | 137d | 2006-07-24 | 2007-01-30 | 0d | start no earlier than 2006-07-24 |
| 148 | MC-MALL RECONFIGURATION MODIFIED |  | 91d | 2006-07-03 | 2006-11-06 | 61d | start no earlier than 2006-07-03 |
| 149 | EXCAVATIONS FOR FOOTINGS & FOUNDATION |  | 45d | 2006-07-24 | 2006-09-22 | 92d | start no earlier than 2006-07-24 |
| 150 | EXCAVATIONS FOR FOOTINGS & FOUNDATION MODIFIED |  | 40d | 2006-07-03 | 2006-08-25 | 112d | start no earlier than 2006-07-03 |
| 151 | INSTALL MASONRY WALL, COLUMN FOOTINGS & SLAB |  | 40d | 2006-08-03 | 2006-09-27 | 89d | start no earlier than 2006-08-03 |
| 152 | INSTALL MASONRY WALL, COLUMN FOOTINGS & SLAB MODIFIED |  | 40d | 2006-07-03 | 2006-08-25 | 112d | start no earlier than 2006-07-03 |
| 153 | CONSTRUCT NEW MASONRY DEMISING PARTITION |  | 40d | 2006-09-18 | 2006-11-10 | 57d | start no earlier than 2006-09-18 |
| 154 | CONSTRUCT NEW MASONRY DEMISING PARTITION MODIFIED |  | 15d | 2006-08-21 | 2006-09-08 | 102d | start no earlier than 2006-08-21 |
| 155 | ERECTION OF NEW STRUCTURAL STEEL & ROOF DECKING |  | 25d | 2006-11-13 | 2006-12-15 | 32d | start no earlier than 2006-11-13 |
| 156 | ERECTION OF NEW STRUCTURAL STEEL & ROOF DECKING MODIFED |  | 25d | 2006-09-11 | 2006-10-13 | 77d | start no earlier than 2006-09-11 |
| 157 | RELOCATION/ ADDITION OF ROOF DRAINAGE |  | 10d | 2006-12-04 | 2006-12-15 | 32d | start no earlier than 2006-12-04 |
| 158 | RELOCATION/ ADDITION OF ROOF DRAINAGE MODIFIED |  | 10d | 2006-10-16 | 2006-10-27 | 67d | start no earlier than 2006-10-16 |
| 159 | INSTALL NEW ROOFING |  | 15d | 2006-12-18 | 2007-01-05 | 17d | start no earlier than 2006-12-18 |
| 160 | INSTALL NEW ROOFING MODIFIED |  | 15d | 2006-10-16 | 2006-11-03 | 62d | start no earlier than 2006-10-16 |
| 161 | ROOF TIE IN AT EXTERIOR WALL |  | 5d | 2006-12-19 | 2006-12-25 | 26d | start no earlier than 2006-12-19 |
| 162 | ROOF TIE IN AT EXTERIOR WALL MODIFIED |  | 5d | 2006-10-30 | 2006-11-03 | 62d | start no earlier than 2006-10-30 |
| 163 | EXTERIOR FINISH OF MASONRY PARTITION |  | 5d | 2006-11-20 | 2006-11-24 | 47d | start no earlier than 2006-11-20 |
| 164 | EXTERIOR FINISH OF MASONRY PARTITION MODIFIED |  | 5d | 2006-09-11 | 2006-09-15 | 97d | start no earlier than 2006-09-11 |
| 165 | RELOCATION OF RTU 2A |  | 5d | 2006-12-20 | 2006-12-26 | 25d | start no earlier than 2006-12-20 |
| 166 | RELOCATION OF RTU 2A MODIFIED |  | 5d | 2006-11-06 | 2006-11-10 | 57d | start no earlier than 2006-11-06 |
| 167 | CONSTRUCT BULK HEAD PARTITION |  | 10d | 2006-10-30 | 2006-11-10 | 57d | start no earlier than 2006-10-30 |
| 168 | CONSTRUCT BULK HEAD PARTITION MODIFIED |  | 10d | 2006-09-13 | 2006-09-26 | 90d | start no earlier than 2006-09-13 |
| 169 | CONSTRUCT NEW DRYWALL CORRIDOR PARTITION |  | 20d | 2006-12-04 | 2006-12-29 | 22d | start no earlier than 2006-12-04 |
| 170 | CONSTRUCT NEW DRYWALL CORRIDOR PARTITION MODIFIED |  | 20d | 2006-09-11 | 2006-10-06 | 82d | start no earlier than 2006-09-11 |
| 171 | INSTALL NEW ROOF TOP UNIT RT2B |  | 5d | 2006-12-20 | 2006-12-26 | 25d | start no earlier than 2006-12-20 |
| 172 | INSTALL NEW ROOF TOP UNIT RT2B MODIFIED |  | 5d | 2006-11-06 | 2006-11-10 | 57d | start no earlier than 2006-11-06 |
| 173 | INSTALL NEW SPRINKLER SYSTEM |  | 10d | 2006-12-29 | 2007-01-11 | 13d | start no earlier than 2006-12-29 |
| 174 | INSTALL NEW SPRINKLER SYSTEM MODIFIED |  | 10d | 2006-09-06 | 2006-09-19 | 95d | start no earlier than 2006-09-06 |
| 175 | INSTALL LIGHTING & FIRE ALARM IN NEW CORRIDOR |  | 10d | 2006-12-29 | 2007-01-11 | 13d | start no earlier than 2006-12-29 |
| 176 | INSTALL LIGHTING & FIRE ALARM IN NEW CORRIDOR MODIFIED |  | 10d | 2006-09-06 | 2006-09-19 | 95d | start no earlier than 2006-09-06 |
| 177 | EXTEND HVAC SYSTEM |  | 5d | 2006-12-27 | 2007-01-02 | 20d | start no earlier than 2006-12-27 |
| 178 | EXTEND HVAC SYSTEM MODIFIED |  | 5d | 2006-09-11 | 2006-09-15 | 97d | start no earlier than 2006-09-11 |
| 179 | COLOT CONCRETE FLOORING AT ENTRY #1 |  | 2d | 2007-01-15 | 2007-01-16 | 10d | start no earlier than 2007-01-15 |
| 180 | COLOT CONCRETE FLOORING AT ENTRY #1 MODIFIED |  | 2d | 2006-09-18 | 2006-09-19 | 95d | start no earlier than 2006-09-18 |
| 181 | FINISH CORRIDOR WALLS |  | 5d | 2007-01-05 | 2007-01-11 | 13d | start no earlier than 2007-01-05 |
| 182 | FINISH CORRIDOR WALLS MODIFIED |  | 5d | 2006-09-15 | 2006-09-21 | 93d | start no earlier than 2006-09-15 |
| 183 | INSTALL SIGNAGE |  | 2d | 2007-01-22 | 2007-01-23 | 5d | start no earlier than 2007-01-22 |
| 184 | INSTALL SIGNAGE MODIFIED |  | 2d | 2006-09-25 | 2006-09-26 | 90d | start no earlier than 2006-09-25 |
| 185 | REMOVE TEMPORARY PEDESTRIAN CORRIDORS |  | 15d | 2007-01-02 | 2007-01-22 | 6d | start no earlier than 2007-01-02 |
| 186 | REMOVE TEMPORARY PEDESTRIAN CORRIDORS MODIFIED |  | 5d | 2006-08-28 | 2006-09-01 | 107d | start no earlier than 2006-08-28 |
| 187 | TEMPORARY PARTITIONS AT ENTRY #1 |  | 5d | 2007-01-15 | 2007-01-19 | 7d | start no earlier than 2007-01-15 |
| 188 | TEMPORARY PARTITIONS AT ENTRY #1 MODIFIED |  | 5d | 2006-09-25 | 2006-09-29 | 87d | start no earlier than 2006-09-25 |
| 189 | INSTALL DOORS & HW AT CORRIDOR AND PARTITION |  | 5d | 2007-01-16 | 2007-01-22 | 6d | start no earlier than 2007-01-16 |
| 190 | INSTALL DOORS & HW AT CORRIDOR AND PARTITION MODIFIED |  | 5d | 2006-09-25 | 2006-09-29 | 87d | start no earlier than 2006-09-25 |
| 191 | COMPLETION OF MALL RECONFIGURATION | milestone | 0d | 2007-01-23 | 2007-01-23 | 5d | finish no earlier than 2007-01-23 |
| 192 | COMPLETION OF MALL RECONFIGURATION MODIFIED | milestone | 0d | 2006-10-02 | 2006-10-02 | 87d | start no earlier than 2006-10-02 |
| 193 | RECEIVE CERTIFICATE OF OCCUPANCY | milestone | 0d | 2007-01-30 | 2007-01-30 | 1d | start no earlier than 2007-01-30 |
| 194 | RECEIVE CERTIFICATE OF OCCUPANCY MODIFIED | milestone | 0d | 2006-11-06 | 2006-11-06 | 62d | start no earlier than 2006-11-06 |
| 195 | ID-INFORMATION DESK RELOCATION |  | 72d | 2006-10-09 | 2007-01-16 | 10d | start no earlier than 2006-10-09 |
| 196 | ID-INFORMATION DESK RELOCATION MODIFIED |  | 20d | 2006-09-11 | 2006-10-06 | 82d | start no earlier than 2006-09-11 |
| 197 | RELOCATION OF ELECTRICAL/ TELCOM COURT #2 |  | 6d | 2006-12-20 | 2006-12-27 | 24d | start no earlier than 2006-12-20 |
| 198 | RELOCATION OF ELECTRICAL/ TELCOM COURT #2 MODIFIED |  | 6d | 2006-09-11 | 2006-09-18 | 96d | start no earlier than 2006-09-11 |
| 199 | PATCH EXISITING CONCRETE SLAB & STAIN |  | 2d | 2006-12-04 | 2006-12-05 | 40d | start no earlier than 2006-12-04 |
| 200 | PATCH EXISITING CONCRETE SLAB & STAIN MODIFIED |  | 2d | 2006-09-18 | 2006-09-19 | 95d | start no earlier than 2006-09-18 |
| 201 | DISASSEMBLE EXISITING INFO DESK AT COURT #1 |  | 5d | 2006-10-09 | 2006-10-13 | 77d | start no earlier than 2006-10-09 |
| 202 | DISASSEMBLE EXISITING INFO DESK AT COURT #1 MODIFIED |  | 5d | 2006-09-25 | 2006-09-29 | 87d | start no earlier than 2006-09-25 |
| 203 | REINSTALL INFO DESK AT COURT #2 |  | 5d | 2007-01-08 | 2007-01-12 | 12d | start no earlier than 2007-01-08 |
| 204 | REINSTALL INFO DESK AT COURT #2 MODIFIED |  | 5d | 2006-09-27 | 2006-10-03 | 85d | start no earlier than 2006-09-27 |
| 205 | CONSTRUCT TEMPORARY PARTITION AT ENTRY #1 |  | 3d | 2006-11-20 | 2006-11-22 | 49d | start no earlier than 2006-11-20 |
| 206 | CONSTRUCT TEMPORARY PARTITION AT ENTRY #1 MODIFIED |  | 3d | 2006-10-04 | 2006-10-06 | 82d | start no earlier than 2006-10-04 |
| 207 | FINAL CONNECTIONS/ MOVE IN |  | 2d | 2007-01-15 | 2007-01-16 | 10d | start no earlier than 2007-01-15 |
| 208 | FINAL CONNECTIONS/ MOVE IN MODIFIED |  | 2d | 2006-10-04 | 2006-10-05 | 83d | start no earlier than 2006-10-04 |
| 209 | COMPLETE RELOCATION OF INFO DESK | milestone | 0d | 2007-01-16 | 2007-01-16 | 11d | start no earlier than 2007-01-16 |
| 210 | COMPLETE RELOCATION OF INFO DESK MODIFIED | milestone | 0d | 2006-10-06 | 2006-10-06 | 83d | start no earlier than 2006-10-06 |
