# TECH2 SCHEDactual

Schedule from MS Project, 2005-11-18 to 2007-01-30.
ae

## Calendars

- Standard: Mon-Fri 08:00-12:00, 13:00-17:00; Sat-Sun off.

## Schedule

| ID | Task | Type | Duration | Start | Finish | Total slack | Constraint |
| --- | --- | --- | --- | --- | --- | --- | --- |
| 1 | PERMITS-PERMITS |  | 222d | 2005-11-18 | 2006-09-25 | 49d | start no earlier than 2005-11-18 |
| 2 | SUBMIT SITE IMPROVEMENTS PERMIT #1 | milestone | 0d | 2005-11-18 | 2005-11-18 | 271d | start no earlier than 2005-11-18 |
| 3 | MDC BUILDING DEPT. SITE IMPROVEMENTS PERMIT #1 |  | 42d | 2005-11-21 | 2006-01-17 | 228d | start no earlier than 2005-11-21 |
| 4 | WASD CONTRACT PLAN PROCEEDURE |  | 45d | 2005-12-05 | 2006-02-03 | 215d | start no earlier than 2005-12-05 |
| 5 | SFWM ERP PERMIT MODIFICATION |  | 90d | 2005-12-05 | 2006-04-07 | 170d | start no earlier than 2005-12-05 |
| 6 | SUBMIT BUILDING PERMIT #2 | milestone | 0d | 2005-12-14 | 2005-12-14 | 253d | start no earlier than 2005-12-14 |
| 7 | MDC BUILDING DEPT. REVIEW BUILDING PERMIT #2 |  | 42d | 2005-12-15 | 2006-02-10 | 210d | start no earlier than 2005-12-15 |
| 8 | MDC BUILDING DEPT. REVIEW BUILDING PERMIT #2 RESUBMISSION |  | 15d | 2006-07-31 | 2006-08-18 | 75d | start no earlier than 2006-07-31 |
| 9 | DRY UTILITY NOTIFICATION | milestone | 0d | 2006-01-03 | 2006-01-03 | 239d | start no earlier than 2006-01-03 |
| 10 | RECEIVE SITEWORK PERMIT #1 | milestone | 0d | 2006-04-03 | 2006-04-03 | 175d | start no earlier than 2006-04-03 |
| 11 | RECEIVE BUILDING PERMIT #2 | milestone | 0d | 2006-06-30 | 2006-06-30 | 111d | start no earlier than 2006-06-30 |
| 12 | RECEIVE BUILDING PERMIT #2 RESUBMISSION | milestone | 0d | 2006-08-18 | 2006-08-18 | 76d | start no earlier than 2006-08-18 |
| 13 | FINAL WASD APPROVAL REVIEW |  | 25d | 2006-08-22 | 2006-09-25 | 49d | finish no earlier than 2006-09-25 |
| 14 | DERM SEWAR CONNECTION PERMIT REVIEW |  | 10d | 2006-09-08 | 2006-09-21 | 51d | start no earlier than 2006-09-08 |
| 15 | MDC HRS WATER CONNECTION PERMIT REVIEW |  | 10d | 2006-09-08 | 2006-09-21 | 51d | start no earlier than 2006-09-08 |
| 16 | DERM SEWAR CONNECTION PERMIT | milestone | 0d | 2006-09-21 | 2006-09-21 | 52d | start no earlier than 2006-09-21 |
| 17 | MIAMI DADE COUNTY HRS WATER CONNECTION | milestone | 0d | 2006-09-25 | 2006-09-25 | 50d | start no earlier than 2006-09-25 |
| 18 | SITE-SITE WORK |  | 139d | 2006-05-22 | 2006-11-30 | 1d | start no earlier than 2006-05-22 |
| 19 | MOBILIZATION | milestone | 0d | 2006-05-22 | 2006-05-22 | 140d | start no earlier than 2006-05-22 |
| 20 | INSTALL CONSTRUCTION FENCING & GATES |  | 5d | 2006-05-22 | 2006-05-26 | 135d | start no earlier than 2006-05-22 |
| 21 | INSTALL ENVIRONMENTAL/ EROSION CONTROL |  | 6d | 2006-06-02 | 2006-06-09 | 125d | start no earlier than 2006-06-02 |
| 22 | EXISTING LANDSCAPE REMOVAL |  | 5d | 2006-06-12 | 2006-06-16 | 120d | start no earlier than 2006-06-12 |
| 23 | REMOVE/ RELOCATE ELECTRICAL LINES |  | 15d | 2006-07-05 | 2006-07-25 | 93d | start no earlier than 2006-07-05 |
| 24 | REMOVE EXISTING PAVING |  | 10d | 2006-07-05 | 2006-07-18 | 98d | start no earlier than 2006-07-05 |
| 25 | REMOVAL/ RELOCATION OF INLETS & SITE DRAINAGE |  | 20d | 2006-07-17 | 2006-08-11 | 80d | start no earlier than 2006-07-17 |
| 26 | START BASS PRO SHOP SITE WORK | milestone | 0d | 2006-08-21 | 2006-08-21 | 75d | start no earlier than 2006-08-21 |
| 27 | REMOVE/ RELOCATE EXISTING ELEC SERVICE METERS |  | 5d | 2006-08-22 | 2006-08-28 | 69d | start no earlier than 2006-08-22 |
| 28 | TRANSFORMER PAD & PIPING |  | 15d | 2006-08-22 | 2006-09-11 | 59d | start no earlier than 2006-08-22 |
| 29 | BASS PRO SHOP PAD PREP |  | 22d | 2006-08-22 | 2006-09-20 | 52d | start no earlier than 2006-08-22 |
| 30 | INSTALL PARKING LIGHT FIXTURES |  | 10d | 2006-08-28 | 2006-09-08 | 60d | start no earlier than 2006-08-28 |
| 31 | REMOVAL/ RELOCATION OF EXISTING WATER SERVICE |  | 35d | 2006-09-26 | 2006-11-13 | 14d | start no earlier than 2006-09-26 |
| 32 | RELOCATION OF FIRE HYDRANT |  | 5d | 2006-09-14 | 2006-09-20 | 52d | start no earlier than 2006-09-14 |
| 33 | BASS PRO PAD CERTIFICATION |  | 12d | 2006-11-14 | 2006-11-29 | 2d | start no earlier than 2006-11-14 |
| 34 | REPAVING & STRIPPING OF SOUTH PARKING AREA |  | 10d | 2006-09-29 | 2006-10-12 | 36d | start no earlier than 2006-09-29 |
| 35 | INSTALL NEW CURBING AT PARKING AREAS |  | 5d | 2006-09-29 | 2006-10-05 | 41d | start no earlier than 2006-09-29 |
| 36 | BASS PRO SHOP PAD TURNOVER | milestone | 0d | 2006-11-29 | 2006-11-29 | 3d | start no earlier than 2006-11-29 |
| 37 | BASS PRO SHOP SITEWORK COMPLETED | milestone | 0d | 2006-11-29 | 2006-11-29 | 3d | start no earlier than 2006-11-29 |
| 38 | LANDSCAPING |  | 15d | 2006-11-06 | 2006-11-24 | 5d | start no earlier than 2006-11-06 |
| 39 | RELOCATION OF IRRIGATION SYSTEM |  | 10d | 2006-10-19 | 2006-11-01 | 22d | start no earlier than 2006-10-19 |
| 40 | INSTALL RING ROAD CURBING & PAVING |  | 10d | 2006-11-16 | 2006-11-29 | 2d | start no earlier than 2006-11-16 |
| 41 | BASS PRO SHOP-BOAT STORAGE |  | 113d | 2006-06-05 | 2006-11-08 | 17d | start no earlier than 2006-06-05 |
| 42 | MOBILIZATION | milestone | 0d | 2006-06-05 | 2006-06-05 | 130d | start no earlier than 2006-06-05 |
| 43 | INSTALL CONSTRUCTION FENCE & GATE |  | 5d | 2006-06-12 | 2006-06-16 | 120d | start no earlier than 2006-06-12 |
| 44 | ROUGH GRADE SITE |  | 15d | 2006-06-19 | 2006-07-07 | 105d | start no earlier than 2006-06-19 |
| 45 | RUN ELECTRICAL SERVICE FROM MALL |  | 20d | 2006-07-14 | 2006-08-10 | 81d | start no earlier than 2006-07-14 |
| 46 | INSTALL SITE DRAINAGE SYSTEM |  | 10d | 2006-07-17 | 2006-07-28 | 90d | start no earlier than 2006-07-17 |
| 47 | EXCAVATE/ INSTALL CONCRETE FOOTINGS |  | 25d | 2006-08-07 | 2006-09-08 | 60d | start no earlier than 2006-08-07 |
| 48 | CONSTRUCT MASONRY BOAT STORAGE ENCLOSURE |  | 30d | 2006-09-11 | 2006-10-20 | 30d | start no earlier than 2006-09-11 |
| 49 | COMPLETE ELECTRICAL SERVICE |  | 5d | 2006-09-28 | 2006-10-04 | 42d | start no earlier than 2006-09-28 |
| 50 | INSTALL SITE LIGHTING |  | 5d | 2006-09-28 | 2006-10-04 | 42d | start no earlier than 2006-09-28 |
| 51 | INSTALL WATER & SEWAR LINE |  | 20d | 2006-09-21 | 2006-10-18 | 32d | start no earlier than 2006-09-21 |
| 52 | FOOTING & MASONRY WALL AT WATER LINE |  | 15d | 2006-10-09 | 2006-10-27 | 25d | start no earlier than 2006-10-09 |
| 53 | PROVIDE ROAD CUTTING & FINAL GRADING |  | 5d | 2006-10-26 | 2006-11-01 | 22d | start no earlier than 2006-10-26 |
| 54 | PAVING |  | 5d | 2006-11-02 | 2006-11-08 | 17d | start no earlier than 2006-11-02 |
| 55 | INSTALL ENTRY GATES |  | 5d | 2006-10-31 | 2006-11-06 | 19d | start no earlier than 2006-10-31 |
| 56 | LANDSCAPPING |  | 10d | 2006-10-31 | 2006-11-13 | 14d | start no earlier than 2006-10-31 |
| 57 | BOAT STORAGE COMPLETED | milestone | 0d | 2006-11-08 | 2006-11-08 | 18d | start no earlier than 2006-11-08 |
| 58 | DEMO-DEMOLITION |  | 50d | 2006-07-10 | 2006-09-15 | 55d | start no earlier than 2006-07-10 |
| 59 | MOBILIZATION | milestone | 0d | 2006-07-10 | 2006-07-10 | 105d | start no earlier than 2006-07-10 |
| 60 | SELECTIVE DEMOLITION |  | 30d | 2006-07-10 | 2006-08-18 | 75d | start no earlier than 2006-07-10 |
| 61 | SAFE OFF RELOCATE EXISITING UTILITIES |  | 20d | 2006-07-10 | 2006-08-04 | 85d | start no earlier than 2006-07-10 |
| 62 | CUT IN DOORS & SUPPORT STEEL @ TILT UP PANELS |  | 10d | 2006-08-16 | 2006-08-29 | 68d | start no earlier than 2006-08-16 |
| 63 | FRAMING/ SHEATHING TEMP CORRIDOR NORTH |  | 30d | 2006-07-17 | 2006-08-25 | 70d | start no earlier than 2006-07-17 |
| 64 | FRAMING/ SHEATHING TEMP CORRIDOR SOUTH |  | 30d | 2006-07-17 | 2006-08-25 | 70d | start no earlier than 2006-07-17 |
| 65 | REMOVAL OF EXISTING SLAB, FOOTINGS & PILES |  | 28d | 2006-07-17 | 2006-08-23 | 72d | start no earlier than 2006-07-17 |
| 66 | REMOVAL EXISTING UTILITIES & RTU 2A |  | 15d | 2006-07-20 | 2006-08-09 | 82d | start no earlier than 2006-07-20 |
| 67 | ELECTRICAL/ FIRE ALARM IN NORTH CORRIDOR |  | 15d | 2006-08-28 | 2006-09-15 | 55d | start no earlier than 2006-08-28 |
| 68 | FIRE PROTECTION NORTH CORRIDOR |  | 15d | 2006-08-28 | 2006-09-15 | 55d | start no earlier than 2006-08-28 |
| 69 | ELECTRICAL/ FIRE ALARM IN SOUTH CORRIDOR |  | 15d | 2006-08-28 | 2006-09-15 | 55d | start no earlier than 2006-08-28 |
| 70 | FIRE PROTECTION SOUTH CORRIDOR |  | 15d | 2006-08-28 | 2006-09-15 | 55d | start no earlier than 2006-08-28 |

| ID | Task | Type | Duration | Start | Finish | Total slack | Constraint |
| --- | --- | --- | --- | --- | --- | --- | --- |
| 71 | DEMOLITION OF EXISITING EXTERIOR SHELL |  | 20d | 2006-08-21 | 2006-09-15 | 55d | start no earlier than 2006-08-21 |
| 72 | CUT BACK EXISITING ROOFING |  | 10d | 2006-08-31 | 2006-09-13 | 57d | start no earlier than 2006-08-31 |
| 73 | TEMPORARY PROTECTION EXISITING MALL EXTERIOR |  | 10d | 2006-08-28 | 2006-09-08 | 60d | start no earlier than 2006-08-28 |
| 74 | TEMPORARY EXTERIOR WALL AT COURT #1 |  | 10d | 2006-08-28 | 2006-09-08 | 60d | start no earlier than 2006-08-28 |
| 75 | MC-MALL RECONFIGURATION |  | 137d | 2006-07-24 | 2007-01-30 | 0d | start no earlier than 2006-07-24 |
| 76 | EXCAVATIONS FOR FOOTINGS & FOUNDATION |  | 45d | 2006-07-24 | 2006-09-22 | 92d | start no earlier than 2006-07-24 |
| 77 | INSTALL MASONRY WALL, COLUMN FOOTINGS & SLAB |  | 40d | 2006-08-03 | 2006-09-27 | 89d | start no earlier than 2006-08-03 |
| 78 | CONSTRUCT NEW MASONRY DEMISING PARTITION |  | 40d | 2006-09-18 | 2006-11-10 | 57d | start no earlier than 2006-09-18 |
| 79 | ERECTION OF NEW STRUCTURAL STEEL & ROOF DECKING |  | 25d | 2006-11-13 | 2006-12-15 | 32d | start no earlier than 2006-11-13 |
| 80 | RELOCATION/ ADDITION OF ROOF DRAINAGE |  | 10d | 2006-12-04 | 2006-12-15 | 32d | start no earlier than 2006-12-04 |
| 81 | INSTALL NEW ROOFING |  | 15d | 2006-12-18 | 2007-01-05 | 17d | start no earlier than 2006-12-18 |
| 82 | ROOF TIE IN AT EXTERIOR WALL |  | 5d | 2006-12-19 | 2006-12-25 | 26d | start no earlier than 2006-12-19 |
| 83 | EXTERIOR FINISH OF MASONRY PARTITION |  | 5d | 2006-11-20 | 2006-11-24 | 47d | start no earlier than 2006-11-20 |
| 84 | RELOCATION OF RTU 2A |  | 5d | 2006-12-20 | 2006-12-26 | 25d | start no earlier than 2006-12-20 |
| 85 | CONSTRUCT BULK HEAD PARTITION |  | 10d | 2006-10-30 | 2006-11-10 | 15d | start no earlier than 2006-10-30 |
| 86 | CONSTRUCT NEW DRYWALL CORRIDOR PARTITION |  | 20d | 2006-12-04 | 2006-12-29 | 22d | start no earlier than 2006-12-04 |
| 87 | INSTALL NEW ROOF TOP UNIT RT2B |  | 5d | 2006-12-20 | 2006-12-26 | 25d | start no earlier than 2006-12-20 |
| 88 | INSTALL NEW SPRINKLER SYSTEM |  | 10d | 2006-12-29 | 2007-01-11 | 13d | start no earlier than 2006-12-29 |
| 89 | INSTALL LIGHTING & FIRE ALARM IN NEW CORRIDOR |  | 10d | 2006-12-29 | 2007-01-11 | 13d | start no earlier than 2006-12-29 |
| 90 | EXTEND HVAC SYSTEM |  | 5d | 2006-12-27 | 2007-01-02 | 20d | start no earlier than 2006-12-27 |
| 91 | COLOT CONCRETE FLOORING AT ENTRY #1 |  | 2d | 2007-01-15 | 2007-01-16 | 10d | start no earlier than 2007-01-15 |
| 92 | FINISH CORRIDOR WALLS |  | 5d | 2007-01-05 | 2007-01-11 | 13d | start no earlier than 2007-01-05 |
| 93 | INSTALL SIGNAGE |  | 2d | 2007-01-22 | 2007-01-23 | 5d | start no earlier than 2007-01-22 |
| 94 | REMOVE TEMPORARY PEDESTRIAN CORRIDORS |  | 15d | 2007-01-02 | 2007-01-22 | 6d | start no earlier than 2007-01-02 |
| 95 | TEMPORARY PARTITIONS AT ENTRY #1 |  | 5d | 2007-01-15 | 2007-01-19 | 7d | start no earlier than 2007-01-15 |
| 96 | INSTALL DOORS & HW AT CORRIDOR AND PARTITION |  | 5d | 2007-01-16 | 2007-01-22 | 6d | start no earlier than 2007-01-16 |
| 97 | COMPLETION OF MALL RECONFIGURATION | milestone | 0d | 2007-01-23 | 2007-01-23 | 5d | finish no earlier than 2007-01-23 |
| 98 | RECEIVE CERTIFICATE OF OCCUPANCY | milestone | 0d | 2007-01-30 | 2007-01-30 | 1d | start no earlier than 2007-01-30 |
| 99 | ID-INFORMATION DESK RELOCATION |  | 72d | 2006-10-09 | 2007-01-16 | 10d | start no earlier than 2006-10-09 |
| 100 | RELOCATION OF ELECTRICAL/ TELCOM COURT #2 |  | 6d | 2006-12-20 | 2006-12-27 | 24d | start no earlier than 2006-12-20 |
| 101 | PATCH EXISITING CONCRETE SLAB & STAIN |  | 2d | 2006-12-04 | 2006-12-05 | 40d | start no earlier than 2006-12-04 |
| 102 | DISASSEMBLE EXISITING INFO DESK AT COURT #1 |  | 5d | 2006-10-09 | 2006-10-13 | 77d | start no earlier than 2006-10-09 |
| 103 | REINSTALL INFO DESK AT COURT #2 |  | 5d | 2007-01-08 | 2007-01-12 | 12d | start no earlier than 2007-01-08 |
| 104 | CONSTRUCT TEMPORARY PARTITION AT ENTRY #1 |  | 3d | 2006-11-20 | 2006-11-22 | 49d | start no earlier than 2006-11-20 |
| 105 | FINAL CONNECTIONS/ MOVE IN |  | 2d | 2007-01-15 | 2007-01-16 | 10d | start no earlier than 2007-01-15 |
| 106 | COMPLETE RELOCATION OF INFO DESK | milestone | 0d | 2007-01-16 | 2007-01-16 | 11d | start no earlier than 2007-01-16 |
